# MAGEEC Gantt

Schedule from MS Project, 2013-06-01 to 2014-11-30.

## Calendars

- Standard: Mon-Fri 08:00-12:00, 13:00-17:00; Sat-Sun off.

## Schedule

| ID | WBS | Task | Type | Duration | Start | Finish | Predecessors | Total slack |
| --- | --- | --- | --- | --- | --- | --- | --- | --- |
| 1 | 1 | **MAGEEC** |  | 390d | 2013-06-01 | 2014-11-30 |  | 0d |
| 2 | 1.1 | WP1: Iterative Design of Compiler Framework | manual | 67d | 2013-06-01 | 2013-08-31 |  |  |
| 3 | 1.2 | WP2: Iterative Implementation of Compiler Framework | manual | 327d | 2013-09-01 | 2014-11-30 | 2, 6 |  |
| 4 | 1.3 | WP3: Design and Build of Hardware Measurement Platform | manual | 44d | 2013-06-01 | 2013-07-31 |  |  |
| 5 | 1.4 | WP4: Training Set, Test Program, Test Hardware and Case Study Development | manual | 66d | 2013-07-01 | 2013-09-30 | 4 |  |
| 6 | 1.5 | WP5: Theory of Analysis of Machine Learning Techniques | manual | 306d | 2013-07-01 | 2014-08-31 |  |  |
| 7 | 1.6 | WP6: Theory of New Optimisation Passes | manual | 46d | 2013-07-01 | 2013-08-31 |  |  |
| 8 | 1.7 | WP7: Training and Testing Prototype Infrastructure | manual | 67d | 2014-03-01 | 2014-05-31 | 3, 5, 9, 2 |  |
| 9 | 1.8 | WP8: Implement New Optimisation Passes | manual | 197d | 2013-09-01 | 2014-05-31 | 7 |  |
| 10 | 1.9 | WP9: Evaluation of Infrastructure | manual | 132d | 2014-06-01 | 2014-11-30 | 8 |  |
| 11 | 1.10 | WP10: Dissemination and Exploitation | manual | 392d | 2013-06-01 | 2014-11-30 |  |  |
